# Non_CMS_Assembly20120403

Schedule from MS Project, 2015-01-01 to 2022-12-21.
KEK

## Calendars

- 標準: Mon-Fri 08:00-12:00, 13:00-17:00; Sat-Sun off.

## Resources

| Resource |
| --- |
| 250t |
| 30t |
| Area5 |
| Area2 |
| Area3 |
| Crawler crane |
| Area1+ |
| Area1- |
| 500t |
| 2.8t- |
| 2.8t+ |
| Area4+ |
| Area4- |
| Area4 |

## Schedule

| ID | WBS | Task | Type | Duration | Start | Finish | Predecessors | Total slack | Free slack | Constraint | Resources | Work |
| --- | --- | --- | --- | --- | --- | --- | --- | --- | --- | --- | --- | --- |
| 1 | 1 | Ground breaking | milestone | 0d | 2015-01-01 | 2015-01-01 |  | 0d |  | start no earlier than 2015-01-01 |  |  |
| 2 | 2 | **Beam lines construction** |  | 1954d | 2015-01-01 | 2022-06-28 |  | 16d |  |  |  | 560h |
| 3 | 2.1 | Tunnel |  | 912d | 2015-01-01 | 2018-06-29 | 1 | 6d | 0d |  |  |  |
| 4 | 2.2 | Beamline harware install |  | 912d | 2018-07-02 | 2021-12-28 | 3 | 6d | 0d |  |  |  |
| 5 | 2.3 | Beam line shield |  | 60d | 2021-08-19 | 2021-11-10 | 37 | 50d | 34d |  | 250t | 480h |
| 6 | 2.4 | Start of beam commissioning | milestone | 0d | 2021-12-28 | 2021-12-28 | 5, 4 | 6d | 0d |  |  |  |
| 7 | 2.5 | BDS pre-commissioning |  | 120d | 2021-12-29 | 2022-06-14 | 6 | 16d | 0d |  |  |  |
| 8 | 2.6 | Shield removal |  | 10d | 2022-06-15 | 2022-06-28 | 7 | 16d | 0d |  | 250t | 80h |
| 9 | 2.7 | BDS ready for detectors | milestone | 0d | 2022-06-28 | 2022-06-28 | 8 | 6d |  |  |  |  |
| 10 | 3 | **Experimental Hall** |  | 1170d | 2015-01-01 | 2019-06-26 |  | 0d |  |  |  |  |
| 11 | 3.1 | Access tunnel |  | 360d | 2015-01-01 | 2016-05-18 | 1 | 0d |  |  |  |  |
| 12 | 3.2 | Cavern |  | 680d | 2016-05-19 | 2018-12-26 | 11 | 0d |  |  |  |  |
| 13 | 3.3 | Services |  | 130d | 2018-12-27 | 2019-06-26 | 12 | 0d |  |  |  |  |
| 14 | 4 | **Detector construction on surface** |  | 1890d | 2015-01-01 | 2022-03-30 |  | 60d |  |  |  |  |
| 15 | 4.1 | Surface assembly hall |  | 390d | 2015-01-01 | 2016-06-29 | 1 | 75d | 0d |  |  |  |
| 16 | 4.2 | Detector assembly on surface |  | 300w | 2016-06-30 | 2022-03-30 | 15 | 200d |  |  |  |  |
| 17 | 4.3 | Solenoid construction |  | 720d | 2016-06-30 | 2019-04-03 | 15 | 920d | 0d |  |  |  |
| 18 | 4.4 | Solenoid surface test |  | 60d | 2019-04-04 | 2019-06-26 | 17 | 920d |  |  |  |  |
| 19 | 4.5 | **Yoke pre-assembly** |  | 1085d | 2016-06-30 | 2020-08-26 |  | 80d |  |  |  |  |
| 20 | 4.5.1 | YB0 modules |  | 250d | 2016-06-30 | 2017-06-14 | 15 | 80d | 0d |  |  |  |
| 21 | 4.5.2 | YE+ modules |  | 250d | 2017-06-15 | 2018-05-30 | 20 | 75d | 0d |  |  |  |
| 22 | 4.5.3 | YE- modules |  | 250d | 2018-05-31 | 2019-05-15 | 21 | 75d | 0d |  |  |  |
| 23 | 4.5.4 | YB+ modules |  | 250d | 2019-05-16 | 2020-04-29 | 22 | 75d |  |  |  |  |
| 24 | 4.5.5 | YB- modules |  | 250d | 2019-09-12 | 2020-08-26 | 40, 28 | 120d | 110d |  |  |  |

| ID | WBS | Task | Duration | Start | Finish | Predecessors | Total slack | Free slack | Resources | Work |
| --- | --- | --- | --- | --- | --- | --- | --- | --- | --- | --- |
| 25 | 5 | **Detector assembly in cavern** | 700d | 2019-06-27 | 2022-03-02 |  | 0d |  |  | 29440h |
| 26 | 5.1 | **Yoke assembly** | 560d | 2019-06-27 | 2021-08-18 |  | 10d |  |  | 7600h |
| 27 | 5.1.1 | Tentative platform in area4 | 50d | 2019-06-27 | 2019-09-04 | 13 | 15d | 5d | Crawler crane; Area4 | 800h |
| 28 | 5.1.2 | YB0 | 50d | 2019-06-27 | 2019-09-04 | 13, 20 | 10d | 0d | 250t; Area1+; Area1- | 1200h |
| 29 | 5.1.3 | YE1+, Muon det install/cabling | 100d | 2019-09-12 | 2020-01-29 | 27, 21, 40 | 10d | 0d | 250t; Area4 | 1600h |
| 30 | 5.1.4 | YE+ move to platform | 5d | 2020-01-30 | 2020-02-05 | 29 | 10d | 0d | Area4; Area1+ | 80h |
| 31 | 5.1.5 | YE-, Muon det install/cabling | 100d | 2020-02-06 | 2020-06-24 | 30, 22 | 10d | 0d | 250t; Area4 | 1600h |
| 32 | 5.1.6 | YE- move to platform | 5d | 2020-06-25 | 2020-07-01 | 31 | 10d |  | Area4; Area1- | 80h |
| 33 | 5.1.7 | YB+ | 50d | 2020-07-30 | 2020-10-07 | 32, 51, 23 | 15d | 10d | 250t; Area4 | 800h |
| 34 | 5.1.8 | YB+ move to platform | 5d | 2020-12-31 | 2021-01-06 | 33, 52, 61 | 10d | 0d | Area4; Area1+ | 80h |
| 35 | 5.1.9 | YB- | 50d | 2021-01-07 | 2021-03-17 | 34, 24 | 40d | 0d | 250t; Area4 | 800h |
| 36 | 5.1.10 | YB- move to platform | 5d | 2021-07-01 | 2021-07-07 | 63, 57 | 5d | 0d | Area4; Area1- | 80h |
| 37 | 5.1.11 | Tentative platform disassemble | 30d | 2021-07-08 | 2021-08-18 | 36 | 50d | 0d | 250t; Area4 | 480h |
| 38 | 5.2 | **Solenoid** | 630d | 2019-06-27 | 2021-11-24 |  | 0d |  |  | 2960h |
| 39 | 5.2.1 | Infrastructure | 175d | 2019-06-27 | 2020-02-26 | 13 | 0d |  |  |  |
| 40 | 5.2.2 | Coil transport | 5d | 2019-09-05 | 2019-09-11 | 28, 18 | 10d | 0d | 250t; Area1- | 80h |
| 41 | 5.2.3 | Coil install | 60d | 2019-09-19 | 2019-12-11 | 50, 28, 40 | 10d | 0d | 30t; Area1+; Area1- | 1440h |
| 42 | 5.2.4 | Coil cool down | 20d | 2020-02-27 | 2020-03-25 | 41, 39 | 0d |  |  |  |
| 43 | 5.2.5 | Coil test | 20d | 2020-03-26 | 2020-04-22 | 42, 30, 59 | 0d |  | Area1-; Area1+ | 320h |
| 44 | 5.2.6 | Coil warm up | 20d | 2020-04-23 | 2020-05-20 | 43 | 675d |  |  |  |
| 45 | 5.2.7 | Detector closing | 10d | 2021-07-08 | 2021-07-21 | 49, 67, 36 | 15d | 10d | Area1+; Area1- | 160h |
| 46 | 5.2.8 | Coil cool down | 20d | 2021-07-08 | 2021-08-04 | 49, 67, 36 | 5d | 0d |  |  |
| 47 | 5.2.9 | Field mapping | 60d | 2021-08-05 | 2021-10-27 | 46, 45 | 5d | 0d | Area1+; Area1- | 960h |
| 48 | 5.2.10 | Coil warm up | 20d | 2021-10-28 | 2021-11-24 | 47 | 280d |  |  |  |

| ID | WBS | Task | Duration | Start | Finish | Predecessors | Total slack | Free slack | Resources | Work |
| --- | --- | --- | --- | --- | --- | --- | --- | --- | --- | --- |
| 49 | 5.3 | **Barreal detectors** | 525d | 2019-06-27 | 2021-06-30 |  | 5d |  |  | 7200h |
| 50 | 5.3.1 | HCAL barrel+z assembly | 60d | 2019-06-27 | 2019-09-18 | 13 | 10d | 0d | 30t; Area5 | 960h |
| 51 | 5.3.2 | HCAL barrel+z install | 10d | 2020-07-16 | 2020-07-29 | 68, 50, 32 | 0d |  | 250t; Area1+ | 160h |
| 52 | 5.3.3 | HCAL barrel+z cabling | 50d | 2020-07-30 | 2020-10-07 | 51 | 70d | 60d | Area1+ | 400h |
| 53 | 5.3.4 | HCAL barrel-z assembly | 60d | 2020-01-09 | 2020-04-01 | 58 | 15d |  | 30t; Area5 | 960h |
| 54 | 5.3.5 | HCAL barrel-z install | 10d | 2020-10-22 | 2020-11-04 | 53, 70, 33 | 5d | 0d | 250t; Area1- | 160h |
| 55 | 5.3.6 | HCAL barrel-z cabling | 50d | 2020-11-05 | 2021-01-13 | 54 | 5d | 0d | Area1- | 400h |
| 56 | 5.3.7 | ECAL barrel install | 60d | 2021-01-14 | 2021-04-07 | 55, 70, 34 | 5d | 0d | 30t; Area1-; Area1+ | 1440h |
| 57 | 5.3.8 | ECAL barrel cabling | 60d | 2021-04-08 | 2021-06-30 | 56 | 5d | 0d | Area1-; Area1+ | 960h |
| 58 | 5.3.9 | Muon detector YB0 install | 20d | 2019-12-12 | 2020-01-08 | 41 | 15d | 0d | 30t; Area1+; Area1- | 480h |
| 59 | 5.3.10 | Muon detector YB0 cabling | 20d | 2020-02-06 | 2020-03-04 | 58, 30 | 15d |  | Area1+; Area1- | 320h |
| 60 | 5.3.11 | Muon detector YB+ install | 20d | 2020-11-05 | 2020-12-02 | 33, 54 | 10d | 0d | 250t; Area4 | 320h |
| 61 | 5.3.12 | Muon detector YB+ cabling | 20d | 2020-12-03 | 2020-12-30 | 60 | 10d | 0d | Area4 | 160h |
| 62 | 5.3.13 | Muon detector YB- install | 20d | 2021-03-18 | 2021-04-14 | 35, 60 | 40d | 0d | 250t; Area4 | 320h |
| 63 | 5.3.14 | Muon detector YB- cabling | 20d | 2021-04-15 | 2021-05-12 | 62 | 40d | 35d | Area4 | 160h |
| 64 | 5.4 | **Barrel inner detectors** | 80d | 2021-11-11 | 2022-03-02 |  | 0d |  |  | 1920h |
| 65 | 5.4.1 | TPC install/cabling/test | 40d | 2021-11-11 | 2022-01-05 | 47, 80 | 0d |  | 30t; Area1+; Area1- | 960h |
| 66 | 5.4.2 | SIT/FTD/VTX install/cabling/test | 40d | 2022-01-06 | 2022-03-02 | 65 | 0d |  | 30t; Area1+; Area1- | 960h |
| 67 | 5.5 | **Endcap detectors** | 310d | 2020-04-23 | 2021-06-30 |  | 0d |  |  | 5760h |
| 68 | 5.5.1 | HCAL endcap+z install | 60d | 2020-04-23 | 2020-07-15 | 53, 30, 43 | 0d |  | 30t; Area1+ | 960h |
| 69 | 5.5.2 | HCAL endcap+z cabling | 60d | 2020-07-16 | 2020-10-07 | 68 | 80d | 0d | Area2 | 480h |
| 70 | 5.5.3 | HCAL endcap-z install | 60d | 2020-07-30 | 2020-10-21 | 68, 32, 51 | 0d |  | 30t; Area1- | 960h |
| 71 | 5.5.4 | HCAL endcap-z cabling | 60d | 2020-10-22 | 2021-01-13 | 70 | 0d |  | Area3 | 480h |
| 72 | 5.5.5 | ECAL endcap+z install | 60d | 2020-10-08 | 2020-12-30 | 69 | 80d | 0d | 2.8t+; Area2 | 960h |
| 73 | 5.5.6 | ECAL endcap+z cabling | 60d | 2020-12-31 | 2021-03-24 | 72 | 80d |  | Area2 | 480h |
| 74 | 5.5.7 | ECAL endcap-z install | 60d | 2021-01-14 | 2021-04-07 | 71 | 0d |  | 2.8t-; Area3 | 960h |
| 75 | 5.5.8 | ECAL endcap-z cabling | 60d | 2021-04-08 | 2021-06-30 | 74 | 0d |  | Area3 | 480h |

| ID | WBS | Task | Type | Duration | Start | Finish | Predecessors | Total slack | Resources | Work |
| --- | --- | --- | --- | --- | --- | --- | --- | --- | --- | --- |
| 76 | 5.6 | **QD0/FCALs install/cabling/test** |  | 125d | 2021-07-01 | 2021-12-22 |  | 0d |  | 4000h |
| 77 | 5.6.1 | Supprt pillar/tube assemble |  | 30d | 2021-07-01 | 2021-08-11 | 75 | 0d | 2.8t+; Area2; Area3; 2.8t- | 960h |
| 78 | 5.6.2 | QD0 install |  | 30d | 2021-08-12 | 2021-09-22 | 77 | 0d | 2.8t+; Area2; Area3; 2.8t- | 960h |
| 79 | 5.6.3 | BCAL install |  | 30d | 2021-09-23 | 2021-11-03 | 78 | 0d | 2.8t+; Area2; Area3; 2.8t- | 960h |
| 80 | 5.6.4 | Detector opening |  | 5d | 2021-11-04 | 2021-11-10 | 47, 79 | 0d | Area1+; Area1-; Area2; Area3 | 160h |
| 81 | 5.6.5 | LUMICAL install |  | 30d | 2021-11-11 | 2021-12-22 | 80 | 50d | 2.8t+; Area2; Area3; 2.8t- | 960h |
| 82 | 6 | **Commissioning** |  | 210d | 2022-03-03 | 2022-12-21 |  | 0d |  |  |
| 83 | 6.1 | Detector pre-commissioning |  | 100d | 2022-03-03 | 2022-07-20 | 66, 76 | 0d |  |  |
| 84 | 6.2 | Detector roll-in |  | 30d | 2022-07-21 | 2022-08-31 | 83, 9 | 0d |  |  |
| 85 | 6.3 | Detector check-out |  | 20d | 2022-09-01 | 2022-09-28 | 84 | 0d |  |  |
| 86 | 6.4 | Final beam commissioning |  | 60d | 2022-09-29 | 2022-12-21 | 85 | 0d |  |  |
| 87 | 6.5 | Ready for physics run | milestone | 0d | 2022-12-21 | 2022-12-21 | 86 | 0d |  |  |
